# Planning_LFR_PFM_21avril2015_v2

Schedule from MS Project, 2014-07-09 to 2015-12-11, 7 hours a day, A marks actual dates.
CNRS - LESIA

## Calendars

- Standard: Mon-Fri 09:00-12:00, 14:00-18:00; Sat-Sun off. Exceptions (off unless hours are given): 2015-08-03 to 2015-08-14 (fermeture estivale).

## Schedule

| ID | WBS | Task | Type | Duration | Start | Finish | Predecessors | Complete | Remaining | Baseline 1 start | Baseline 1 finish | Total slack | Constraint | Text9 |
| --- | --- | --- | --- | --- | --- | --- | --- | --- | --- | --- | --- | --- | --- | --- |
| 1 | 1 | GO PFM | milestone, manual | 0d | 2015-06-26 | 2015-06-26 |  |  |  |  |  |  |  |  |
| 2 | 2 | LFR/TCS EQM delivey to LESIA | milestone, manual | 0d | 2015-05-07 | 2015-05-07 |  |  |  |  |  |  |  |  |
| 3 | 3 | **Hardware developments** |  | 363d | 2014-07-09 A | 2015-12-11 |  |  | 363d | 2014-04-07 | 2015-10-30 | 0d |  | LFR |
| 4 | 3.1 | **LFR FM HW design and development** |  | 363d | 2014-07-09 A | 2015-12-11 |  |  | 363d | 2014-07-09 | 2015-10-30 | 0d |  | LFR |
| 5 | 3.1.1 | Kick off PCB |  | 1d | 2015-05-07 | 2015-05-07 | 2 |  |  |  |  | 0d |  |  |
| 6 | 3.1.2 | H/W definition and schematics (update) |  | 5d | 2015-05-08 | 2015-05-14 | 5 |  |  | 2015-03-10 | 2015-03-30 | 0d |  | LFR |
| 7 | 3.1.3 | PCB layout |  | 5d | 2015-05-15 | 2015-05-21 | 6 |  |  | 2015-03-31 | 2015-04-13 | 0d |  | LFR |
| 8 | 3.1.4 | KP PCB layout |  | 1d | 2015-05-22 | 2015-05-22 | 7 |  |  | 2015-04-13 | 2015-04-13 | 0d |  | LFR |
| 9 | 3.1.5 | layout update |  | 2d | 2015-05-25 | 2015-05-26 | 8 |  |  |  |  | 0d |  |  |
| 10 | 3.1.6 | PCB Manufacturing kickoff |  | 1d | 2015-05-27 | 2015-05-27 | 9 |  |  |  |  | 0d |  |  |
| 11 | 3.1.7 | MRR |  | 1d | 2015-06-26 | 2015-06-26 | 9, 1 |  |  | 2015-04-14 | 2015-04-14 | 28d |  | LFR |
| 12 | 3.1.8 | PCB manufacturing |  | 50d | 2015-05-28 | 2015-08-19 | 10 |  |  | 2015-04-14 | 2015-06-12 | 0d |  | LFR |
| 13 | 3.1.9 | TCS Parts procurement | milestone | 0d | 2014-07-09 A | 2014-07-09 A |  | 100% |  | 2014-07-09 | 2015-05-28 |  | start no earlier than 2014-07-09 | LFR |
| 14 | 3.1.10 | LFR Parts procurement | milestone | 0d | 2015-04-21 | 2015-04-21 |  |  |  | 2015-05-28 | 2015-05-28 | 162d |  | LFR |
| 15 | 3.1.11 | **LFR FM HW design,dev & tests** |  | 82d | 2015-08-20 | 2015-12-11 |  |  |  | 2015-06-15 | 2015-10-30 | 0d |  | LFR |
| 16 | 3.1.11.1 | Board population |  | 20d | 2015-08-20 | 2015-09-16 | 12, 11 |  |  | 2015-06-16 | 2015-07-29 | 0d |  | LFR |
| 17 | 3.1.11.2 | FPGA PROTO validation (at STEEL?) | milestone | 3d | 2015-09-17 | 2015-09-21 | 16 |  |  | 2015-07-30 | 2015-07-30 | 0d |  | LFR |
| 18 | 3.1.11.3 | FPGA FM programming |  | 2d | 2015-09-22 | 2015-09-23 | 17 |  |  |  |  | 0d |  |  |
| 19 | 3.1.11.4 | FPGA FM validation (at STEEL?) |  | 3d | 2015-09-24 | 2015-09-28 | 18 |  |  |  |  | 0d |  |  |
| 20 | 3.1.11.5 | FPGA FM soldering |  | 3d | 2015-09-29 | 2015-10-01 | 19 |  |  | 2015-07-31 | 2015-08-20 | 0d |  | LFR |
| 21 | 3.1.11.6 | FM final validation + delivery to LPP |  | 1d | 2015-10-02 | 2015-10-02 | 20 |  |  | 2015-08-21 | 2015-08-21 | 0d |  | LFR |
| 22 | 3.1.11.7 | TRR preparation (documentation) | milestone | 0d | 2015-10-02 | 2015-10-02 | 21 |  |  | 2015-08-21 | 2015-08-21 | 53d |  | LFR |
| 23 | 3.1.11.8 | Boards ready for TRR | milestone | 0d | 2015-10-02 | 2015-10-02 | 21 |  |  | 2015-08-21 | 2015-08-21 | 0d |  | LFR |
| 24 | 3.1.11.9 | TRR |  | 1d | 2015-10-05 | 2015-10-05 | 23 |  |  | 2015-08-24 | 2015-08-24 | 0d |  | LFR |
| 25 | 3.1.11.10 | Board full fonctionnal and performance tests |  | 5d | 2015-10-06 | 2015-10-12 | 24 |  |  | 2015-08-25 | 2015-09-07 | 0d |  | LFR |
| 26 | 3.1.11.11 | Validation FSW R3 |  | 10d | 2015-10-13 | 2015-10-26 | 25 |  |  |  |  | 0d |  |  |
| 27 | 3.1.11.12 | Calibration |  | 10d | 2015-10-27 | 2015-11-09 | 26 |  |  | 2015-09-08 | 2015-09-21 | 0d |  | LFR |
| 28 | 3.1.11.13 | Board EMC Tests |  | 5d | 2015-11-10 | 2015-11-16 | 27 |  |  | 2015-09-22 | 2015-09-28 | 0d |  | LFR |
| 29 | 3.1.11.14 | Board back to STEEL |  | 1d | 2015-11-17 | 2015-11-17 | 28 |  |  | 2015-09-29 | 2015-09-30 | 0d |  | LFR |
| 30 | 3.1.11.15 | MIP |  | 1d | 2015-11-18 | 2015-11-18 | 29 |  |  | 2015-10-01 | 2015-10-01 | 0d |  | LFR |
| 31 | 3.1.11.16 | Coating & Final mechanical integretion |  | 5d | 2015-11-19 | 2015-11-25 | 30 |  |  | 2015-10-02 | 2015-10-09 | 0d |  | LFR |
| 32 | 3.1.11.17 | Delivery to LPP |  | 1d | 2015-11-26 | 2015-11-26 | 31 |  |  | 2015-10-12 | 2015-10-12 | 0d |  | LFR |
| 33 | 3.1.11.18 | Post-coating tests and characterization |  | 5d | 2015-11-27 | 2015-12-03 | 32 |  |  | 2015-10-13 | 2015-10-19 | 0d |  | LFR |
| 34 | 3.1.11.19 | Final delivery to LPP | milestone | 0d | 2015-12-03 | 2015-12-03 | 33 |  |  | 2015-10-19 | 2015-10-19 | 0d |  | LFR |
| 35 | 3.1.11.20 | Board thermal tests (if any) |  | 3d | 2015-12-04 | 2015-12-08 | 34 |  |  | 2015-10-20 | 2015-10-22 | 0d |  | LFR |
| 36 | 3.1.11.21 | TRB/DRB preparation (datapackage) |  | 2d | 2015-12-09 | 2015-12-10 | 35 |  |  | 2015-10-23 | 2015-10-29 | 0d |  | LFR |
| 37 | 3.1.11.22 | TRB and DRB |  | 1d | 2015-12-11 | 2015-12-11 | 36 |  |  | 2015-10-30 | 2015-10-30 | 0d |  | LFR |
| 38 | 3.1.11.23 | LFR FM ready for delivery to lesia for AIT MEB | milestone | 0d | 2015-12-11 | 2015-12-11 | 37 |  |  | 2015-10-30 | 2015-10-30 | 0d |  | LFR |

Notes:
- 3: Text26: NC Hardware developments / Text30: 29/10/15 Hardware developments
- 4: Text26: NC FM HW design and development / Text30: 29/10/15 LFR FM HW design and development
- 6: Text26: NC H/W definition and schematics (update) / Text30: 21/01/11 H/W definition and schematics (update)
- 7: Text26: NC PCB layout / Text30: 07/04/15 PCB layout
- 8: Text26: NC KP PCB layout / Text30: 07/04/15 KP PCB layout
- 11: Text26: NC MRR preparation (documentation) / Text30: 08/04/15 MRR preparation (documentation)
- 12: Text26: NC PCB manufacturing / Text30: 08/06/15 PCB manufacturing
- 13: Text26: NC TCS Parts procurement / Text30: 28/05/15 TCS Parts procurement
- 14: Text26: NC LFR FM Parts available for assembly / Text30: 28/05/15 LFR FM Parts available for assembly
- 15: Text26: NC LFR FM HW assembly & tests / Text30: 29/10/15 LFR FM HW design,dev & tests
- 16: Text26: NC Parts assembly and Integration in mechanical frame / Text30: 28/07/15 Parts assembly and Integration in mechanical frame
- 17: Text26: NC LFR FM FPGA validation in the dedicated socket (at STEEL) / Text30: 29/07/15 LFR FM FPGA validation in the dedicated socket (at STEEL)
- 20: Text26: NC FPGA soldering / Text30: 19/08/15 FPGA soldering
- 21: Text26: NC Final validation by STEEL/LPP / Text30: 20/08/15 Final validation by STEEL/LPP
- 22: Text26: NC TRR preparation (documentation) / Text30: 20/08/15 TRR preparation (documentation)
- 23: Text26: NC Boards ready for TRR / Text30: 20/08/15 Boards ready for TRR
- 24: Text26: NC TRR / Text30: 21/08/15 TRR
- 25: Text26: NC Board full fonctionnal and performance tests / Text30: 04/09/15 Board full fonctionnal and performance tests
- 27: Text26: NC Calibration / Text30: 18/09/15 Calibration
- 28: Text26: NC Board EMC Tests / Text30: 25/09/15 Board EMC Tests
- 29: Text26: NC Board back to STEEL / Text30: 29/09/15 Board back to STEEL
- 30: Text26: NC MIP / Text30: 30/09/15 MIP
- 31: Text26: NC Coating & Final mechanical integretion / Text30: 08/10/15 Coating & Final mechanical integretion
- 32: Text26: NC Delivery to LPP / Text30: 09/10/15 Delivery to LPP
- 33: Text26: NC Post-coating tests and characterization / Text30: 16/10/15 Post-coating tests and characterization
- 34: Text26: NC Final delivery to LPP / Text30: 16/10/15 Final delivery to LPP
- 35: Text26: NC Board thermal tests (if any) / Text30: 21/10/15 Board thermal tests (if any)
- 36: Text26: NC TRB/DRB preparation (datapackage) / Text30: 28/10/15 TRB/DRB preparation (datapackage)
- 37: Text26: NC TRB and DRB / Text30: 29/10/15 TRB and DRB
- 38: Text26: NC LFR FM ready for delivery to lesia for AIT MEB / Text30: 29/10/15 LFR FM ready for delivery to lesia for AIT MEB

| ID | WBS | Task | Type | Duration | Start | Finish | Predecessors | Complete | Remaining | Baseline 1 start | Baseline 1 finish | Total slack | Free slack | Constraint | Text9 | Text1 | Text26 |
| --- | --- | --- | --- | --- | --- | --- | --- | --- | --- | --- | --- | --- | --- | --- | --- | --- | --- |
| 39 | 4 | **LFR FPGA developments** |  | 192d | 2014-07-25 A | 2015-04-21 |  | 53% | 89.68d | 2014-07-25 | 2015-04-07 | 159d |  |  | LFR |  |  |
| 40 | 4.1 | **EQM firmware** |  | 112.3d | 2014-07-25 A | 2014-12-30 |  | 72% | 31.53d | 2014-07-25 | 2014-12-19 | 238.7d |  |  | LFR |  |  |
| 41 | 4.1.1 | VHDL: waveform picker refinement |  | 91.3d | 2014-08-25 A | 2014-12-30 |  | 78% | 19.8d | 2014-08-25 | 2014-12-18 | 241.7d |  | start no earlier than 2014-08-25 | LFR | A confirmer | NC VHDL: waveform picker refinement |
| 42 | 4.1.2 | **flight RAM evaluation board** |  | 39.5d | 2014-07-25 A | 2014-09-18 |  | 47% | 20.79d | 2014-07-25 | 2014-09-17 | 311.5d |  |  | LFR |  |  |
| 43 | 4.1.2.1 | PCB design and manufacturing |  | 22d | 2014-07-25 | 2014-08-25 |  |  |  | 2014-07-25 | 2014-08-22 | 332d |  | start no earlier than 2014-07-25 | LFR | A confirmer | NC PCB design and manufacturing |
| 44 | 4.1.2.2 | flight RAM bending and cutting |  | 14.3d | 2014-08-25 A | 2014-09-12 A |  | 100% |  | 2014-08-25 | 2014-09-10 |  |  | start no earlier than 2014-08-25 | LFR |  | NC flight RAM bending and cutting |
| 45 | 4.1.2.3 | Board population |  | 5.5d | 2014-09-11 A | 2014-09-18 A | 43, 44 | 100% |  | 2014-09-11 | 2014-09-17 |  |  |  | LFR |  | NC Board population |
| 46 | 4.1.3 | VHDL: flight RAM memory controler |  | 72.6d | 2014-09-18 A | 2014-12-29 | 45 | 71% | 20.9d | 2014-09-18 | 2014-12-19 | 242.4d |  |  | LFR | A confirmer | NC VHDL: flight RAM memory controler |
| 47 | 4.1.4 | Documentation |  | 17.6d | 2014-09-15 A | 2014-10-08 A | 41 | 100% |  | 2014-09-15 | 2014-10-06 |  |  | start no earlier than 2012-01-05 | LFR |  | NC Documentation |
| 48 | 4.2 | **FM firmware** |  | 141d | 2014-10-06 A | 2015-04-21 |  | 24% | 106.56d | 2014-10-06 | 2015-04-07 | 159d |  |  | LFR |  |  |
| 49 | 4.2.1 | VHDL: downsampling filter, all frequencies |  | 66d | 2014-10-06 A | 2015-01-05 |  | 53% | 30.8d | 2014-10-06 | 2015-01-12 | 180.9d | 0d |  | LFR | A confirmer | NC VHDL: downsampling filter, all frequencies |
| 50 | 4.2.2 | VHDL: SCM calibration |  | 22d | 2015-01-06 | 2015-02-04 | 49 |  |  | 2015-01-13 | 2015-02-09 | 215d |  |  | LFR | A confirmer | NC VHDL: SCM calibration |
| 51 | 4.2.3 | VHDL: housekeeping |  | 22d | 2015-01-06 | 2015-02-04 | 49 |  |  | 2015-01-13 | 2015-02-09 | 180.9d | 0d |  | LFR | A confirmer | NC VHDL: housekeeping |
| 52 | 4.2.4 | Completion of the firmware and tests documentation |  | 22d | 2015-02-05 | 2015-03-06 | 51 |  |  | 2015-02-10 | 2015-03-09 | 180.9d | 0d |  | LFR | A confirmer | NC Completion of the firmware and tests documentation |
| 53 | 4.2.5 | Tests result analysis (Cnes / Lesia) |  | 5.5d | 2015-03-09 | 2015-03-16 | 52 |  |  | 2015-03-10 | 2015-03-16 | 180.9d | 0d |  | LFR | A confirmer | NC Tests result analysis (Cnes / Lesia) |
| 54 | 4.2.6 | Validation KP |  | 1.1d | 2015-03-16 | 2015-03-17 | 53 |  |  | 2015-03-17 | 2015-03-17 | 180.9d | 0d |  | LFR |  | NC Validation KP |
| 55 | 4.2.7 | Complementary tests follow-up analysis |  | 5.5d | 2015-03-17 | 2015-03-25 | 54 |  |  | 2015-03-18 | 2015-03-24 | 180.9d | 0d |  | LFR |  | NC Complementary tests follow-up analysis |
| 56 | 4.2.8 | GO / NOGO FM FPGA ready for programmation | milestone | 0d | 2015-03-25 | 2015-03-25 | 55 |  |  | 2015-03-24 | 2015-03-24 | 180.9d |  |  | LFR |  | NC GO / NOGO FM FPGA ready for programmation |
| 57 | 4.2.9 | **PPBI** |  | 0d | 2015-04-21 | 2015-04-21 |  |  |  | 2015-01-14 | 2015-04-07 | 159d |  |  | LFR |  |  |
| 58 | 4.2.9.1 | PPBI: NRE | milestone | 0d | 2015-04-21 | 2015-04-21 |  |  |  | 2015-01-14 | 2015-03-24 | 162d |  |  | LFR | A confirmer | NC PPBI: NRE |
| 59 | 4.2.9.2 | FPGA programmation | milestone | 0d | 2015-04-21 | 2015-04-21 |  |  |  | 2015-03-25 | 2015-03-25 | 162d |  |  | LFR |  | NC FPGA programmation |
| 60 | 4.2.9.3 | PPBI: electrical tests | milestone | 0d | 2015-04-21 | 2015-04-21 |  |  |  | 2015-03-26 | 2015-04-07 | 162d |  |  | LFR |  | NC PPBI: electrical tests |
| 61 | 4.2.10 | Firmware ready for FM assembly | milestone | 0d | 2015-04-21 | 2015-04-21 |  |  |  | 2015-04-07 | 2015-04-07 | 162d |  |  | LFR |  | NC Firmware ready for FM assembly |
| 62 | 5 | **Onboard analyser SW developments** |  | 255.2d | 2014-10-01 | 2015-10-07 |  |  |  | 2014-10-01 | 2015-09-02 | 47.8d |  |  | LFR |  |  |
| 63 | 5.1 | R2 DRB/CDR |  | 2.2d | 2014-10-01 | 2014-10-03 |  |  |  | 2014-10-01 | 2014-10-02 | 50.8d | 0d | start no earlier than 2014-10-01 | LFR | A confirmer | NC R2 DRB/CDR |
| 64 | 5.2 | R3 software |  | 253d | 2014-10-03 | 2015-10-07 | 63 |  |  | 2014-10-03 | 2015-09-02 | 50.8d |  |  | LFR | A confirmer | NC R3 software |

Notes:
- 39: Text30: 07/04/15 LFR FPGA developments
- 40: Text30: 19/12/14 EM2 firmware
- 41: A vérifier / Text30: 18/12/14 VHDL: waveform picker refinement
- 42: Text30: 17/09/14 flight RAM evaluation board
- 43: Text30: 22/08/14 PCB design and manufacturing
- 44: Text30: 10/09/14 flight RAM bending and cutting
- 45: Text30: 17/09/14 Board population
- 46: Text30: 19/12/14 VHDL: flight RAM memory controler
- 47: Text30: 06/10/14 Documentation
- 48: Text30: 07/04/15 FM firmware
- 49: Text30: 12/01/15 VHDL: downsampling filter, all frequencies
- 50: Text30: 09/02/15 VHDL: SCM calibration
- 51: Text30: 09/02/15 VHDL: housekeeping
- 52: Text30: 09/03/15 Completion of the firmware and tests documentation
- 53: Text30: 16/03/15 Tests result analysis (Cnes / Lesia)
- 54: Text30: 17/03/15 Validation KP
- 55: Text30: 24/03/15 Complementary tests follow-up analysis
- 56: Text30: 24/03/15 GO / NOGO FM FPGA ready for programmation
- 57: Text30: 07/04/15 PPBI
- 58: Text30: 24/03/15 PPBI: NRE
- 59: Text30: 25/03/15 FPGA programmation
- 60: Text30: 07/04/15 PPBI: electrical tests
- 61: Text30: 07/04/15 Firmware ready for FM assembly
- 62: Text30: 02/09/15 Onboard analyser SW developments
- 63: Text30: 02/10/14 R2 DRB/CDR
- 64: Text30: 02/09/15 R3 software
